# Chapter2_2011

Schedule from MS Project, 2012-03-05 to 2012-03-26.
University of southern Mississippi

## Calendars

- Standard: Mon-Fri 08:00-12:00, 13:00-17:00; Sat-Sun off.

## Schedule

| ID | Task | Type | Duration | Start | Finish | Predecessors | Baseline start | Baseline finish | Baseline duration | Total slack |
| --- | --- | --- | --- | --- | --- | --- | --- | --- | --- | --- |
| 1 | Clear Site |  | 2d | 2012-03-05 | 2012-03-06 |  | 2001-01-08 | 2001-01-09 | 2d | 0d |
| 2 | Building Layout |  | 1d | 2012-03-07 | 2012-03-07 | 1 | 2001-01-10 | 2001-01-10 | 1d | 0d |
| 3 | Form Slab |  | 2d | 2012-03-08 | 2012-03-09 | 2 | 2001-01-11 | 2001-01-12 | 2d | 0d |
| 4 | Under Slab Plumbing |  | 1d | 2012-03-12 | 2012-03-12 | 3 | 2001-01-11 | 2001-01-11 | 1d | 0d |
| 5 | Prepare Slab for Pour |  | 3d | 2012-03-13 | 2012-03-15 | 4 | 2001-01-12 | 2001-01-16 | 3d | 0d |
| 6 | Inspect Slab | milestone | 0d | 2012-03-15 | 2012-03-15 | 5 |  |  |  | 0d |
| 7 | Pour Slab |  | 1d | 2012-03-16 | 2012-03-16 | 6 | 2001-01-17 | 2001-01-17 | 1d | 0d |
| 8 | Rough Frame Walls |  | 6d | 2012-03-19 | 2012-03-26 | 7 | 2001-01-18 | 2001-01-24 | 5d | 0d |
