# Chapter3_2011

Schedule from MS Project, 2012-03-05 to 2012-03-27, costs in $.
University of southern Mississippi

## Calendars

- Standard: Mon-Fri 08:00-12:00, 13:00-17:00; Sat-Sun off.

## Resources

| Resource | Group | Unit | Rate |
| --- | --- | --- | --- |
| Carpenter - CL1 |  |  | 12 |
| Carpenter - CL2 |  |  | 10 |
| Laborer |  |  | 8 |
| Mason | Mansory Crew |  | 14 |
| Mixer | Mansory Crew |  | 8 |
| Concrete Finisher |  |  | 12 |
| Superintendent |  |  | 16 |
| Dozer |  |  | 10 |
| Trailer |  |  | 8 |
| Masonry Saw | Mansory Crew |  | 1 |
| Radial Arm Saw |  |  | 1 |
| Generator |  |  | 2 |
| Pickup |  |  | 2 |
| Mortar Mixer | Mansory Crew |  | 2 |
| Concrete |  | CY | 50 |

## Schedule

| ID | Task | Type | Duration | Start | Finish | Predecessors | Baseline start | Baseline finish | Baseline duration | Total slack | Free slack | Resources | Work | Cost |
| --- | --- | --- | --- | --- | --- | --- | --- | --- | --- | --- | --- | --- | --- | --- |
| 1 | Clear Site |  | 2d | 2012-03-05 | 2012-03-06 |  | 2001-01-08 | 2001-01-09 | 2d | 0d |  |  |  |  |
| 2 | Building Layout |  | 1d | 2012-03-07 | 2012-03-07 | 1 | 2001-01-10 | 2001-01-10 | 1d | 0d |  |  |  |  |
| 3 | Form Slab |  | 2d | 2012-03-08 | 2012-03-09 | 2 | 2001-01-11 | 2001-01-12 | 2d | 0d |  |  |  |  |
| 4 | Under Slab Plumbing |  | 1d | 2012-03-12 | 2012-03-12 | 3 | 2001-01-11 | 2001-01-11 | 1d | 0d |  |  |  |  |
| 5 | Prepare Slab for Pour |  | 3d | 2012-03-13 | 2012-03-15 | 4 | 2001-01-12 | 2001-01-16 | 3d | 0d |  |  |  |  |
| 6 | Inspect Slab | milestone | 0d | 2012-03-15 | 2012-03-15 | 5 |  |  |  | 0d |  |  |  |  |
| 7 | Pour Slab |  | 1d | 2012-03-16 | 2012-03-16 | 6 | 2001-01-17 | 2001-01-17 | 1d | 0d |  |  |  |  |
| 8 | Rough Frame Walls |  | 2d | 2012-03-19 | 2012-03-20 | 7 | 2001-01-18 | 2001-01-24 | 5d | 0d |  | Carpenter - CL1 [300%]; Carpenter - CL2 [300%]; Laborer [300%] | 144h | 1,440 |
| 9 | Rough Frame Roof |  | 1d? | 2012-03-21 | 2012-03-21 | 8 |  |  |  | 0d |  |  |  |  |
| 10 | Install Doors and Windows |  | 0.4d? | 2012-03-22 | 2012-03-22 | 9 |  |  |  | 3.6d |  | Carpenter - CL1 [200%]; Laborer [300%] | 16h | 153.6 |
| 11 | Install Wall Insulation |  | 1d? | 2012-03-22 | 2012-03-22 | 9 |  |  |  | 0d |  |  |  |  |
| 12 | Rough Plumbing |  | 1d? | 2012-03-22 | 2012-03-22 | 9 |  |  |  | 3d |  |  |  |  |
| 13 | Rough HVAC |  | 1d? | 2012-03-22 | 2012-03-22 | 9 |  |  |  | 3d |  |  |  |  |
| 14 | Rough Electrical |  | 1d? | 2012-03-22 | 2012-03-22 | 9 |  |  |  | 3d |  |  |  |  |
| 15 | Install Shingles |  | 1d? | 2012-03-22 | 2012-03-22 | 9 |  |  |  | 0.6d | 0d |  |  |  |
| 16 | Exterior Finish Carpentry |  | 0.4d? | 2012-03-23 | 2012-03-23 | 15 |  |  |  | 0.6d | 0d | Carpenter - CL1 [200%]; Laborer [300%] | 16h | 153.6 |
| 17 | Hang Drywall |  | 1d? | 2012-03-23 | 2012-03-23 | 11 |  |  |  | 0d |  |  |  |  |
| 18 | Finish Drywall |  | 1d? | 2012-03-26 | 2012-03-26 | 17 |  |  |  | 0d |  |  |  |  |
| 19 | Place Exterior Brick |  | 1d? | 2012-03-23 | 2012-03-26 | 16 |  |  |  | 0.6d | 0d |  |  |  |
| 20 | Place Cabinets |  | 1d? | 2012-03-27 | 2012-03-27 | 18 |  |  |  | 0d |  |  |  |  |
| 21 | Exterior Paint |  | 1d? | 2012-03-26 | 2012-03-27 | 19 |  |  |  | 0.6d |  |  |  | 1,500 |
| 22 | Interior Finish Carpentry |  | 0.4d? | 2012-03-05 | 2012-03-05 |  |  |  |  | 16.6d |  | Carpenter - CL1 [200%]; Laborer [300%] | 16h | 153.6 |
