# Chapter4_2011

Schedule from MS Project, 2012-03-05 to 2012-03-29, status date 2012-03-16, costs in $, A marks actual dates.
University of southern Mississippi

## Calendars

- Standard: Mon-Fri 08:00-12:00, 13:00-17:00; Sat-Sun off.

## Resources

| Resource | Group | Unit | Rate |
| --- | --- | --- | --- |
| Carpenter - CL1 |  |  | 12 |
| Carpenter - CL2 |  |  | 10 |
| Laborer |  |  | 8 |
| Mason | Mansory Crew |  | 14 |
| Mixer | Mansory Crew |  | 8 |
| Concrete Finisher |  |  | 12 |
| Superintendent |  |  | 16 |
| Dozer |  |  | 10 |
| Trailer |  |  | 8 |
| Masonry Saw | Mansory Crew |  | 1 |
| Radial Arm Saw |  |  | 1 |
| Generator |  |  | 2 |
| Pickup |  |  | 2 |
| Mortar Mixer | Mansory Crew |  | 2 |
| Concrete |  | CY | 50 |

## Schedule

| ID | Task | Type | Duration | Start | Finish | Predecessors | Complete | Remaining | Baseline start | Baseline finish | Baseline duration | Total slack | Free slack | Resources | Work | Cost | Baseline cost |
| --- | --- | --- | --- | --- | --- | --- | --- | --- | --- | --- | --- | --- | --- | --- | --- | --- | --- |
| 1 | Clear Site |  | 2d | 2012-03-05 A | 2012-03-06 A |  | 100% |  | 2012-03-05 | 2012-03-06 | 2d |  |  |  |  |  |  |
| 2 | Building Layout |  | 3d | 2012-03-07 A | 2012-03-09 | 1 | 67% | 1d | 2012-03-07 | 2012-03-07 | 1d | 2d | 0d |  |  |  |  |
| 3 | Form Slab |  | 2d | 2012-03-12 | 2012-03-13 | 2 |  |  | 2012-03-08 | 2012-03-09 | 2d | 2d | 0d |  |  |  |  |
| 4 | Under Slab Plumbing |  | 1d | 2012-03-14 | 2012-03-14 | 3 |  |  | 2012-03-12 | 2012-03-12 | 1d | 2d | 0d |  |  |  |  |
| 5 | Prepare Slab for Pour |  | 3d | 2012-03-15 A | 2012-03-19 | 4 | 67% | 1d | 2012-03-13 | 2012-03-15 | 3d | 0d |  |  |  |  |  |
| 6 | Inspect Slab | milestone | 0d | 2012-03-19 | 2012-03-19 | 5 |  |  | 2012-03-15 | 2012-03-15 | 0d | 0d |  |  |  |  |  |
| 7 | Pour Slab |  | 1d | 2012-03-20 | 2012-03-20 | 6 |  |  | 2012-03-16 | 2012-03-16 | 1d | 0d |  |  |  |  |  |
| 8 | Rough Frame Walls |  | 2d | 2012-03-21 | 2012-03-22 | 7 |  |  | 2012-03-19 | 2012-03-20 | 2d | 0d |  | Carpenter - CL1 [300%]; Carpenter - CL2 [300%]; Laborer [300%] | 144h | 1,440 | 1,440 |
| 9 | Rough Frame Roof |  | 1d? | 2012-03-23 | 2012-03-23 | 8 |  |  | 2012-03-21 | 2012-03-21 | 1d? | 0d |  |  |  |  |  |
| 10 | Install Doors and Windows |  | 0.4d? | 2012-03-26 | 2012-03-26 | 9 |  |  | 2012-03-22 | 2012-03-22 | 0.4d? | 3.6d |  | Carpenter - CL1 [200%]; Laborer [300%] | 16h | 153.6 | 153.6 |
| 11 | Install Wall Insulation |  | 1d? | 2012-03-26 | 2012-03-26 | 9 |  |  | 2012-03-22 | 2012-03-22 | 1d? | 0d |  |  |  |  |  |
| 12 | Rough Plumbing |  | 1d? | 2012-03-26 | 2012-03-26 | 9 |  |  | 2012-03-22 | 2012-03-22 | 1d? | 3d |  |  |  |  |  |
| 13 | Rough HVAC |  | 1d? | 2012-03-26 | 2012-03-26 | 9 |  |  | 2012-03-22 | 2012-03-22 | 1d? | 3d |  |  |  |  |  |
| 14 | Rough Electrical |  | 1d? | 2012-03-26 | 2012-03-26 | 9 |  |  | 2012-03-22 | 2012-03-22 | 1d? | 3d |  |  |  |  |  |
| 15 | Install Shingles |  | 1d? | 2012-03-26 | 2012-03-26 | 9 |  |  | 2012-03-22 | 2012-03-22 | 1d? | 0.6d | 0d |  |  |  |  |
| 16 | Exterior Finish Carpentry |  | 0.4d? | 2012-03-27 | 2012-03-27 | 15 |  |  | 2012-03-23 | 2012-03-23 | 0.4d? | 0.6d | 0d | Carpenter - CL1 [200%]; Laborer [300%] | 16h | 153.6 | 153.6 |
| 17 | Hang Drywall |  | 1d? | 2012-03-27 | 2012-03-27 | 11 |  |  | 2012-03-23 | 2012-03-23 | 1d? | 0d |  |  |  |  |  |
| 18 | Finish Drywall |  | 1d? | 2012-03-28 | 2012-03-28 | 17 |  |  | 2012-03-26 | 2012-03-26 | 1d? | 0d |  |  |  |  |  |
| 19 | Place Exterior Brick |  | 1d? | 2012-03-27 | 2012-03-28 | 16 |  |  | 2012-03-23 | 2012-03-26 | 1d? | 0.6d | 0d |  |  |  |  |
| 20 | Place Cabinets |  | 1d? | 2012-03-29 | 2012-03-29 | 18 |  |  | 2012-03-27 | 2012-03-27 | 1d? | 0d |  |  |  |  |  |
| 21 | Exterior Paint |  | 1d? | 2012-03-28 | 2012-03-29 | 19 |  |  | 2012-03-26 | 2012-03-27 | 1d? | 0.6d |  |  |  | 1,500 | 1,500 |
| 22 | Interior Finish Carpentry |  | 0.4d? | 2012-03-05 | 2012-03-05 |  |  |  | 2012-03-05 | 2012-03-05 | 0.4d? | 17.6d |  | Carpenter - CL1 [200%]; Laborer [300%] | 16h | 153.6 | 153.6 |
