# Chapter3a

Schedule from MS Project, 2012-03-05 to 2012-04-30, status date 2012-03-16, costs in $, A marks actual dates.
University of southern Mississippi

## Calendars

- Standard: Mon-Fri 08:00-12:00, 13:00-17:00; Sat-Sun off.

## Resources

| Resource | Group | Unit | Rate | Cost per use | Notes |
| --- | --- | --- | --- | --- | --- |
| Carpenter - Cl1 |  |  | 12 |  | May have problems getting qualified carpenters, after April 1st, due to the number of new projects starting up. |
| Carpenter - CL2 |  |  | 10 |  |  |
| Laborer |  |  | 8 |  |  |
| Mason | Masonry Crew |  | 14 |  |  |
| Mixer | Masonry Crew |  | 8 |  |  |
| Concrete Finisher |  |  | 12 |  |  |
| Superintendent |  |  | 16 |  |  |
| Dozer |  |  | 10 |  |  |
| Trailer |  |  | 8 |  |  |
| Masonry Saw | Masonry Crew |  | 1 |  |  |
| Radial Arm Saw |  |  | 1 |  |  |
| Generator |  |  | 2 |  |  |
| Pickup |  |  | 2 |  |  |
| Mortar Mixer | Masonry Crew |  | 2 | 20 |  |
| Concrete |  | CY | 50 |  |  |
| Sub - Plbg |  |  |  |  |  |
| Sub - HVAC |  |  |  |  |  |
| Sub - Elec |  |  |  |  |  |
| Drywall Finisher |  |  | 9 |  |  |
| Painter |  |  | 9 |  |  |
| Sub - Flooring |  |  |  |  |  |

## Schedule

| ID | Task | Duration | Start | Finish | Predecessors | Complete | Remaining | Baseline start | Baseline finish | Baseline duration | Total slack | Free slack | Resources | Work | Actual work | Cost | Baseline cost | Actual cost |
| --- | --- | --- | --- | --- | --- | --- | --- | --- | --- | --- | --- | --- | --- | --- | --- | --- | --- | --- |
| 1 | Clear Site | 2d | 2012-03-05 A | 2012-03-06 A |  | 100% |  | 2001-01-08 | 2001-01-09 | 2d |  |  | Carpenter - Cl1; Laborer [200%]; Pickup; Dozer | 80h | 80h | 720 | 640 | 720 |
| 2 | Building Layout | 3d | 2012-03-07 A | 2012-03-09 | 1 | 67% | 1d | 2001-01-10 | 2001-01-10 | 1d | 1.98d | 0d | Carpenter - Cl1; Laborer [200%] | 72h | 48h | 672 | 224 | 448 |
| 3 | Form Slab | 2d | 2012-03-12 | 2012-03-13 | 2 |  |  | 2001-01-11 | 2001-01-12 | 2d | 2d |  | Carpenter - Cl1 [200%]; Laborer [200%] | 64h |  | 640 | 640 |  |
| 4 | Under Slab Plumbing | 1d | 2012-03-12 | 2012-03-12 | 2 |  |  | 2001-01-11 | 2001-01-11 | 1d | 1.98d | 0d | Sub - Plbg [200%] | 16h |  |  |  |  |
| 5 | Prepare Slab for Pour | 3d | 2012-03-13 A | 2012-03-15 | 4 | 66% | 1.02d | 2001-01-12 | 2001-01-16 | 3d | 0d |  | Carpenter - Cl1; Laborer [200%] | 72h | 47.52h | 672 | 672 | 443.52 |
| 6 | Pour Slab | 1d | 2012-03-16 | 2012-03-16 | 3, 5 |  |  | 2001-01-17 | 2001-01-17 | 1d | 0d |  | Concrete Finisher [200%]; Laborer [300%] | 40h |  | 384 | 384 |  |
| 7 | Rough Frame Walls | 5d | 2012-03-19 | 2012-03-23 | 6 |  |  | 2001-01-18 | 2001-01-24 | 5d | 0d |  | Carpenter - Cl1 [300%]; Carpenter - CL2 [300%]; Laborer [300%] | 360h |  | 3,600 | 3,600 |  |
| 8 | Rough Frame Roof | 3d | 2012-03-26 | 2012-03-28 | 7 |  |  | 2001-01-25 | 2001-01-29 | 3d | 0d |  | Carpenter - Cl1 [300%]; Carpenter - CL2 [300%]; Laborer [300%] | 216h |  | 2,160 | 2,160 |  |
| 9 | Install Doors and Windows | 2d | 2012-03-26 | 2012-03-27 | 7 |  |  | 2001-01-25 | 2001-01-26 | 2d | 24d |  | Carpenter - Cl1 [200%]; Laborer [300%] | 48h |  | 512 | 512 |  |
| 10 | Install Wall Insulation | 2d | 2012-04-03 | 2012-04-04 | 8, 11, 13 |  |  | 2001-02-02 | 2001-02-05 | 2d | 0d |  | Carpenter - Cl1 [200%]; Laborer [300%] | 80h |  | 768 | 768 |  |
| 11 | Rough Plumbing | 3d | 2012-03-29 | 2012-04-02 | 8 |  |  | 2001-01-30 | 2001-02-01 | 3d | 0d |  | Sub - Plbg [200%] | 48h |  |  |  |  |
| 12 | Rough HVAC | 2d | 2012-03-29 | 2012-03-30 | 8 |  |  | 2001-01-30 | 2001-01-31 | 2d | 3d |  | Sub - HVAC [200%] | 32h |  |  |  |  |
| 13 | Rough Elec | 3d | 2012-03-29 | 2012-04-02 | 8 |  |  | 2001-01-30 | 2001-02-01 | 3d | 0d |  | Sub - Elec [200%] | 48h |  |  |  |  |
| 14 | Install Shingles | 2d | 2012-03-29 | 2012-03-30 | 8 |  |  | 2001-01-30 | 2001-01-31 | 2d | 3d |  | Carpenter - Cl1 [200%]; Laborer [300%] | 80h |  | 768 | 768 |  |
| 15 | Exterior Finish Carpentry | 4d | 2012-04-05 | 2012-04-10 | 10, 14 |  |  | 2001-02-06 | 2001-02-09 | 4d | 0d |  | Carpenter - Cl1 [200%]; Laborer [300%] | 96h |  | 1,024 | 1,024 |  |
| 16 | Hang Drywall | 3d | 2012-04-05 | 2012-04-09 | 10, 12 |  |  | 2001-02-06 | 2001-02-08 | 3d | 0d |  | Carpenter - Cl1; Laborer [200%] | 72h |  | 672 | 672 |  |
| 17 | Finish Drywall | 3d | 2012-04-10 | 2012-04-12 | 16 |  |  | 2001-02-09 | 2001-02-13 | 3d | 0d |  | Drywall Finisher [200%] | 48h |  | 432 | 432 |  |
| 18 | Place Exterior Brick | 4d | 2012-04-11 | 2012-04-16 | 15 |  |  | 2001-02-12 | 2001-02-15 | 4d | 0d |  | Mason [200%]; Mixer; Laborer [200%] | 160h |  | 1,664 | 1,664 |  |
| 19 | Place Cabinets | 1d | 2012-04-13 | 2012-04-13 | 17 |  |  | 2001-02-14 | 2001-02-14 | 1d | 4d |  | Carpenter - Cl1; Carpenter - CL2 | 16h |  | 176 | 176 |  |
| 20 | Exterior Paint | 3d | 2012-04-17 | 2012-04-19 | 15, 18 |  |  | 2001-02-16 | 2001-02-20 | 3d | 0d |  | Painter [300%] | 72h |  | 2,148 | 2,148 |  |
| 21 | Interior Finish Carpentry | 3d | 2012-04-13 | 2012-04-17 | 17 |  |  | 2001-02-14 | 2001-02-16 | 3d | 0d |  | Carpenter - Cl1 [200%]; Laborer [300%] | 72h |  | 768 | 768 |  |
| 22 | Interior Finish Paint | 3d | 2012-04-20 | 2012-04-24 | 23, 24, 25, 20, 19 |  |  | 2001-02-21 | 2001-02-23 | 3d | 0d |  | Painter [300%] | 72h |  | 648 | 648 |  |
| 23 | Interior Finish Plumbing | 2d | 2012-04-18 | 2012-04-19 | 21 |  |  | 2001-02-19 | 2001-02-20 | 2d | 0d |  | Sub - Plbg [200%] | 32h |  |  |  |  |
| 24 | Interior Finish HVAC | 2d | 2012-04-18 | 2012-04-19 | 21 |  |  | 2001-02-19 | 2001-02-20 | 2d | 0d |  | Sub - HVAC [200%] | 32h |  |  |  |  |
| 25 | Interior Finish Elec | 2d | 2012-04-18 | 2012-04-19 | 21 |  |  | 2001-02-19 | 2001-02-20 | 2d | 0d |  | Sub - Elec [200%] | 32h |  |  |  |  |
| 26 | Flooring | 2d | 2012-04-25 | 2012-04-26 | 22 |  |  | 2001-02-26 | 2001-02-27 | 2d | 0d |  | Sub - Flooring [200%] | 32h |  |  |  |  |
| 27 | Prepare Driveways and Walks | 4d | 2012-03-16 | 2012-03-21 | 5 |  |  | 2001-01-17 | 2001-01-22 | 4d | 25d | 0d | Carpenter - Cl1; Laborer [200%] | 96h |  | 896 | 896 |  |
| 28 | Pour Driveways and Walks | 1d | 2012-03-22 | 2012-03-22 | 27 |  |  | 2001-01-23 | 2001-01-23 | 1d | 25d |  | Concrete Finisher [200%]; Laborer [300%] | 40h |  | 384 | 384 |  |
| 29 | Punch List | 2d | 2012-04-27 | 2012-04-30 | 28, 26 |  |  | 2001-02-28 | 2001-03-01 | 2d | 0d |  | Carpenter - Cl1; Painter; Sub - Elec; Sub - HVAC; Sub - Plbg | 80h |  | 336 | 336 |  |
